# Simple Project Plan

How a schedule from MS Project changed from version to version. A marks actual dates.

## Version 1 (saved 2018-08-05, file Learning Team C Wk5 Rev A.mpp)

| ID | WBS | Task | Duration | Start | Finish | Predecessors | Complete | Total float | Constraint |
| --- | --- | --- | --- | --- | --- | --- | --- | --- | --- |
| 1 |  | 1.0 POM+ Project | 1d? | 2019-01-03 | 2019-01-03 |  |  |  |  |
| 2 | 2 | **1.1 R&D product development** | 55d | 2012-01-03 A | 2012-03-19 A |  | 100% |  |  |
| 3 |  | 1.1.1 Need survey | 23d | 2012-01-03 A | 2012-02-02 A |  | 100% |  | start no earlier than 2012-01-03 |
| 4 |  | 1.1.2 Set product specs | 18d | 2012-02-03 A | 2012-02-28 A | 3 | 100% |  | finish no earlier than 2012-02-28 |
| 5 |  | 1.1.3 Shelf life report | 10d | 2012-02-29 A | 2012-03-13 A | 4 | 100% |  |  |
| 6 |  | 1.1.4 Nutrition report | 4d | 2012-03-14 A | 2012-03-19 A |  | 100% |  | start no earlier than 2012-03-14 |
| 7 |  | 1.2 Secure fruit suppliers | 20d | 2012-03-20 A | 2012-04-16 | 5, 6 | 50% | 1683d |  |
| 8 | 4 | **1.3 Initial Production** | 90d | 2012-02-29 A | 2012-07-03 |  | 19% | 1682d |  |
| 9 |  | 1.3.1 Equipment rehab | 35d | 2012-02-29 A | 2012-04-17 | 4 | 50% | 1682d |  |
| 10 |  | 1.3.2 Production trials | 15d | 2012-04-18 | 2012-05-08 | 9, 7 |  | 1682d |  |
| 11 |  | 1.3.3 Quality trials | 20d | 2012-05-09 | 2012-06-05 | 10 |  | 1682d |  |
| 12 |  | 1.3.4 Quality metrics | 5d | 2012-06-06 | 2012-06-12 | 11 |  | 1682d |  |
| 13 |  | 1.3.5 Quality training | 15d | 2012-06-13 | 2012-07-03 | 12 |  | 1682d |  |
| 14 | 5 | **1.4 Distribution** | 85d | 2012-03-20 | 2012-07-16 |  |  | 1673d |  |
| 15 |  | 1.4.1 Market testing | 30d | 2012-04-24 | 2012-06-25 | 5, 6 |  | 1648d |  |
| 16 |  | 1.4.2 Package design | 15d | 2012-06-26 | 2012-07-16 | 15 |  | 1673d |  |
| 17 |  | 1.4.3 Select distributors | 25d | 2012-03-20 | 2012-04-23 | 5, 6 |  | 1733d |  |
| 18 | 6 | **1.5 Legal** | 15d | 2012-06-26 | 2012-07-16 |  |  | 1648d |  |
| 19 |  | 1.5.1 Complete FDA certification | 15d | 2012-06-26 | 2012-07-16 | 7, 15 |  | 1648d |  |
| 20 |  | 1.5.2 Register trademark | 5d | 2012-06-26 | 2012-07-02 | 7, 15 |  | 1668d |  |
| 21 |  | 1.6 Prepare product launch | 15d | 2012-08-21 | 2012-09-10 | 13, 16, 17, 19FS+25d, 20FS+15d |  | 1648d |  |

## Version 2 (data date 2012-03-31, saved 2018-08-05, file Learning Team C Wk5 Rev_E.mpp)

Last finish 2019-01-03 → 2012-07-31 (-2347d).

Changed:

| ID | Task | Start | Finish | Duration | Complete | Total float | Predecessors | Other |
| --- | --- | --- | --- | --- | --- | --- | --- | --- |
| 1 | 1.0 POM+ Project | 2019-01-03 → 2012-01-03 (-2557d) | 2019-01-03 → 2012-01-03 (-2557d) |  |  |  |  | baseline start none → 2012-01-03; baseline finish none → 2012-01-03 |
| 2 | **1.1 R&D product development** |  | 2012-03-19 A → 2012-03-01 (-18d) | 55d → 42.5d |  |  |  | baseline start none → 2012-01-03; baseline finish none → 2012-03-01 |
| 3 | 1.1.1 Need survey |  |  |  |  |  |  | constraint start no earlier than 2012-01-03 → none; baseline start none → 2012-01-03; baseline finish none → 2012-01-30 |
| 4 | 1.1.2 Set product specs |  |  |  |  |  |  | constraint finish no earlier than 2012-02-28 → none; baseline start none → 2012-01-31; baseline finish none → 2012-02-09 |
| 5 | 1.1.3 Shelf life report |  |  |  |  |  |  | baseline start none → 2012-02-09; baseline finish none → 2012-02-23 |
| 6 | 1.1.4 Nutrition report |  |  |  |  |  | none → 4 | constraint start no earlier than 2012-03-14 → none; baseline start none → 2012-02-27; baseline finish none → 2012-03-02 |
| 7 | 1.2 Secure fruit suppliers | 2012-03-20 A → 2012-03-07 (-13d) | 2012-04-16 → 2012-04-03 (-13d) |  | 50% → 0% | 1683d → none |  | baseline start none → 2012-03-07; baseline finish none → 2012-04-03 |
| 8 | **1.3 Initial Production** |  | 2012-07-03 → 2012-06-19 (-14d) | 90d → 80d | 19% → 26% | 1682d → 0d |  | baseline start none → 2012-02-09; baseline finish none → 2012-06-19 |
| 9 | 1.3.1 Equipment rehab |  |  |  | 50% → 66% | 1682d → 5d |  | baseline start none → 2012-02-09; baseline finish none → 2012-03-22 |
| 10 | 1.3.2 Production trials |  |  |  |  | 1682d → 5d |  | baseline start none → 2012-04-04; baseline finish none → 2012-04-24 |
| 11 | 1.3.3 Quality trials |  |  |  |  | 1682d → 5d |  | baseline start none → 2012-04-25; baseline finish none → 2012-05-22 |
| 12 | 1.3.4 Quality metrics |  |  |  |  | 1682d → 5d |  | baseline start none → 2012-05-23; baseline finish none → 2012-05-29 |
| 13 | 1.3.5 Quality training | 2012-06-13 → 2012-05-30 (-14d) | 2012-07-03 → 2012-06-19 (-14d) |  |  | 1682d → none |  | baseline start none → 2012-05-30; baseline finish none → 2012-06-19 |
| 14 | **1.4 Distribution** | 2012-03-20 → 2012-03-07 (-13d) | 2012-07-16 → 2012-06-12 (-34d) | 85d → 70d |  | 1673d → none |  | baseline start none → 2012-03-07; baseline finish none → 2012-06-12 |
| 15 | 1.4.1 Market testing | 2012-04-24 → 2012-04-11 (-13d) | 2012-06-25 → 2012-05-22 (-34d) |  |  | 1648d → none |  | baseline start none → 2012-04-11; baseline finish none → 2012-05-22 |
| 16 | 1.4.2 Package design | 2012-06-26 → 2012-04-18 (-69d) | 2012-07-16 → 2012-06-12 (-34d) | 15d → 40d |  | 1673d → none |  | baseline start none → 2012-04-18; baseline finish none → 2012-06-12 |
| 17 | 1.4.3 Select distributors | 2012-03-20 → 2012-03-07 (-13d) | 2012-04-23 → 2012-04-10 (-13d) |  |  | 1733d → none |  | baseline start none → 2012-03-07; baseline finish none → 2012-04-10 |
| 18 | **1.5 Legal** | 2012-06-26 → 2012-04-18 (-69d) | 2012-07-16 → 2012-06-19 (-27d) | 15d → 45d |  | 1648d → none |  | baseline start none → 2012-04-18; baseline finish none → 2012-06-19 |
| 19 | 1.5.1 Complete FDA certification | 2012-06-26 → 2012-04-18 (-69d) | 2012-07-16 → 2012-05-22 (-55d) |  |  | 1648d → none |  | baseline start none → 2012-04-18; baseline finish none → 2012-05-22 |
| 20 | 1.5.2 Register trademark | 2012-06-26 → 2012-06-13 (-13d) | 2012-07-02 → 2012-06-19 (-13d) |  |  | 1668d → none |  | baseline start none → 2012-06-13; baseline finish none → 2012-06-19 |
| 21 | 1.6 Prepare product launch | 2012-08-21 → 2012-07-11 (-41d) | 2012-09-10 → 2012-07-31 (-41d) |  |  | 1648d → none |  | baseline start none → 2012-07-11; baseline finish none → 2012-07-31 |

## Version 3 (saved 2020-06-03, file Part1.mpp)

Last finish 2012-07-31 → 2020-12-07 (+3051d). Complete tasks 4 → 0.

Added:

| ID | Task | Duration | Start | Finish | Predecessors |
| --- | --- | --- | --- | --- | --- |
| 1 | **POM+Project** | 135d | 2020-06-02 | 2020-12-07 |  |
| 7 | Secure fruit suppliers | 20d | 2020-08-04 | 2020-08-31 | 5, 6 |
| 13 | Quality training | 15d | 2020-10-27 | 2020-11-16 | 12 |
| 18 | **Legal** | 15d | 2020-09-15 | 2020-10-05 |  |

Removed: 17 1.4.3 Select distributors; 18 1.5 Legal; 19 1.5.1 Complete FDA certification; 20 1.5.2 Register trademark

Changed:

| ID | Task | Start | Finish | Duration | Complete | Total float | Predecessors | Other |
| --- | --- | --- | --- | --- | --- | --- | --- | --- |
| 2 | **R&D product development** | 2012-06-06 → 2020-06-02 (+2918d) | 2012-06-12 → 2020-08-31 (+3002d) | 5d → 65d |  | 5d → 0d | 12 → none | was named 1.3.4 Quality metrics; resources Quality Engineering [300%]; Production → none; baseline start 2012-05-23 → none; baseline finish 2012-05-29 → none |
| 3 | Need survey | 2012-01-03 A → 2020-06-02 (+3073d) | 2012-03-01 → 2020-06-29 (+3042d) | 42.5d → 20d | 100% → 0% | none → 0d |  | was named 1.1 R&D product development; baseline start 2012-01-03 → none; baseline finish 2012-03-01 → none |
| 4 | Set product specs | 2012-01-03 A → 2020-06-30 (+3101d) | 2012-02-02 A → 2020-07-20 (+3091d) | 23d → 15d | 100% → 0% | none → 0d | none → 3 | was named 1.1.1 Need survey; resources Marketing Staff [500%] → none; baseline start 2012-01-03 → none; baseline finish 2012-01-30 → none |
| 5 | Shelf life report | 2012-02-03 A → 2020-07-21 (+3091d) | 2012-02-28 A → 2020-08-03 (+3079d) | 18d → 10d | 100% → 0% | none → 0d |  | was named 1.1.2 Set product specs; resources Marketing Staff [400%]; R&D [200%] → none; baseline start 2012-01-31 → none; baseline finish 2012-02-09 → none |
| 6 | Nutrition report | 2012-05-30 → 2020-07-21 (+2974d) | 2012-06-19 → 2020-07-27 (+2960d) | 15d → 5d |  | none → 5d | 2 → 4 | was named 1.3.5 Quality training; resources Quality Engineering [300%]; Production [1500%] → none; baseline start 2012-05-30 → none; baseline finish 2012-06-19 → none |
| 8 | **Initial Production** | 2012-02-29 A → 2020-07-21 (+3065d) | 2012-03-13 A → 2020-11-16 (+3170d) | 10d → 85d | 100% → 0% | none → 0d | 5 → none | was named 1.1.3 Shelf life report; resources R&D [300%] → none; baseline start 2012-02-09 → none; baseline finish 2012-02-23 → none |
| 9 | Equipment rabab | 2012-02-29 A → 2020-07-21 (+3065d) | 2012-06-19 → 2020-08-31 (+2995d) | 80d → 30d | 26% → 0% |  | none → 4 | was named 1.3 Initial Production; baseline start 2012-02-09 → none; baseline finish 2012-06-19 → none |
| 10 | Production trials | 2012-02-29 A → 2020-09-01 (+3107d) | 2012-04-17 → 2020-09-21 (+3079d) | 35d → 15d | 66% → 0% | 5d → 0d | 5 → 7, 9 | was named 1.3.1 Equipment rehab; resources Engineering [1000%]; Production [2000%] → none; baseline start 2012-02-09 → none; baseline finish 2012-03-22 → none |
| 11 | Quality trials | 2012-04-18 → 2020-09-22 (+3079d) | 2012-05-08 → 2020-10-19 (+3086d) | 15d → 20d |  | 5d → 0d | 10, 21 → 10 | was named 1.3.2 Production trials; resources Production [1500%]; Purchasing; Engineering [1000%] → none; baseline start 2012-04-04 → none; baseline finish 2012-04-24 → none |
| 12 | Quality metrics | 2012-05-09 → 2020-10-20 (+3086d) | 2012-06-05 → 2020-10-26 (+3065d) | 20d → 5d |  | 5d → 0d |  | was named 1.3.3 Quality trials; resources Quality Engineering [300%]; Production [500%] → none; baseline start 2012-04-25 → none; baseline finish 2012-05-22 → none |
| 14 | **Distribution** | 2012-03-07 → 2020-08-04 (+3072d) | 2012-06-12 → 2020-10-19 (+3051d) | 70d → 55d |  | none → 5d |  | was named 1.4 Distribution; baseline start 2012-03-07 → none; baseline finish 2012-06-12 → none |
| 15 | Market testing | 2012-04-11 → 2020-08-04 (+3037d) | 2012-05-22 → 2020-09-14 (+3037d) |  |  | none → 5d | 8, 20 → 5, 6 | was named 1.4.1 Market testing; resources Marketing Staff [500%] → none; baseline start 2012-04-11 → none; baseline finish 2012-05-22 → none |
| 16 | Package design | 2012-04-18 → 2020-09-15 (+3072d) | 2012-06-12 → 2020-10-05 (+3037d) | 40d → 15d |  | none → 30d |  | was named 1.4.2 Package design; resources Designers [300%]; Marketing Staff → none; baseline start 2012-04-18 → none; baseline finish 2012-06-12 → none |
| 17 | Select distributors | 2012-07-11 → 2020-09-15 (+2988d) | 2012-07-31 → 2020-10-19 (+3002d) | 15d → 25d |  | none → 20d | 6, 16, 1.4.3 Select distributors, 1.5.1 Complete FDA certificationFS+25d, 1.5.2 Register trademarkFS+15d → 7, 15 | was named 1.6 Prepare product launch; resources Quality Engineering [300%]; Purchasing [200%]; Production [1500%]; Marketing Staff [500%]; Engineering [500%]; R&D → none; baseline start 2012-07-11 → none; baseline finish 2012-07-31 → none |
| 19 | Complete FDA certification | 2012-01-03 → 2020-09-15 (+3178d) | 2012-01-03 → 2020-10-05 (+3198d) | 1d? → 15d |  | none → 5d | none → 7, 15 | was named 1.0 POM+ Project; baseline start 2012-01-03 → none; baseline finish 2012-01-03 → none |
| 20 | Register trademark | 2012-03-14 A → 2020-09-15 (+3107d) | 2012-03-19 A → 2020-09-21 (+3108d) | 4d → 5d | 100% → 0% | none → 25d | 5 → 7, 15 | was named 1.1.4 Nutrition report; resources R&D [300%] → none; baseline start 2012-02-27 → none; baseline finish 2012-03-02 → none |
| 21 | Prepare product launch | 2012-03-07 → 2020-11-17 (+3177d) | 2012-04-03 → 2020-12-07 (+3170d) | 20d → 15d |  | none → 0d | 8, 20 → 13, 16, 17, 19FS+25d, 20FS+15d | was named 1.2 Secure fruit suppliers; resources Purchasing → none; baseline start 2012-03-07 → none; baseline finish 2012-04-03 → none |

## Version 4 (saved 2020-06-07, file POM 1.mpp)

Last finish 2020-12-07 → 2021-07-09 (+214d).

Changed:

| ID | Task | Start | Finish | Duration | Total float | Other |
| --- | --- | --- | --- | --- | --- | --- |
| 1 | **POM+Project** | 2020-06-02 → 2021-01-04 (+216d) | 2020-12-07 → 2021-07-09 (+214d) |  |  |  |
| 2 | **R&D product development** | 2020-06-02 → 2021-01-04 (+216d) | 2020-08-31 → 2021-04-02 (+214d) |  |  |  |
| 3 | Need survey | 2020-06-02 → 2021-01-04 (+216d) | 2020-06-29 → 2021-01-29 (+214d) |  |  | constraint none → start no earlier than 2021-01-04; resources none → MRKT |
| 4 | Set product specs | 2020-06-30 → 2021-02-01 (+216d) | 2020-07-20 → 2021-02-19 (+214d) |  |  | resources none → R&D [400%]; MRKT [200%] |
| 5 | Shelf life report | 2020-07-21 → 2021-02-22 (+216d) | 2020-08-03 → 2021-03-05 (+214d) |  |  | resources none → R&D [300%] |
| 6 | Nutrition report | 2020-07-21 → 2021-03-04 (+226d) | 2020-07-27 → 2021-03-05 (+221d) | 5d → 1.67d | 5d → 0d | resources none → R&D [300%] |
| 7 | Select fruit suppliers | 2020-08-04 → 2021-03-08 (+216d) | 2020-08-31 → 2021-04-02 (+214d) |  |  | was named Secure fruit suppliers; resources none → PURCH |
| 8 | **Initial Praduction** | 2020-07-21 → 2021-02-22 (+216d) | 2020-11-16 → 2021-06-18 (+214d) |  |  | was named Initial Production |
| 9 | Equipmant rabab | 2020-07-21 → 2021-02-22 (+216d) | 2020-08-31 → 2021-04-02 (+214d) |  |  | was named Equipment rabab; resources none → ENG [1000%]; PROD [2000%] |
| 10 | Production trials | 2020-09-01 → 2021-04-05 (+216d) | 2020-09-21 → 2021-04-23 (+214d) |  |  | resources none → PROD [1500%]; PURCH; ENG [1000%] |
| 11 | Quality trials | 2020-09-22 → 2021-04-26 (+216d) | 2020-10-19 → 2021-05-21 (+214d) |  |  | resources none → QUAL [300%]; PROD [500%] |
| 12 | Quality metrics | 2020-10-20 → 2021-05-24 (+216d) | 2020-10-26 → 2021-05-28 (+214d) |  |  | resources none → QUAL [300%]; PROD |
| 13 | Quality training | 2020-10-27 → 2021-05-31 (+216d) | 2020-11-16 → 2021-06-18 (+214d) |  |  | resources none → QUAL [300%]; PROD |
| 14 | **Distribution** | 2020-08-04 → 2021-03-08 (+216d) | 2020-10-19 → 2021-06-11 (+235d) | 55d → 70d |  |  |
| 15 | Market testing | 2020-08-04 → 2021-03-08 (+216d) | 2020-09-14 → 2021-04-16 (+214d) |  |  | resources none → MRKT [500%] |
| 16 | Package design | 2020-09-15 → 2021-04-19 (+216d) | 2020-10-05 → 2021-06-11 (+249d) | 15d → 30d | 30d → 5d | resources none → DESIGN [300%]; MRKT |
| 17 | Select distributors | 2020-09-15 → 2021-04-19 (+216d) | 2020-10-19 → 2021-05-21 (+214d) |  |  | resources none → MRKT [500%] |
| 18 | **Legal** | 2020-09-15 → 2021-04-19 (+216d) | 2020-10-05 → 2021-05-14 (+221d) | 15d → 20d |  |  |
| 19 | Complete FDA certification | 2020-09-15 → 2021-04-19 (+216d) | 2020-10-05 → 2021-05-07 (+214d) |  |  | resources none → LEGAL [500%] |
| 20 | Register trademark | 2020-09-15 → 2021-05-10 (+237d) | 2020-09-21 → 2021-05-14 (+235d) |  | 25d → 10d | resources none → LEGAL [300%] |
| 21 | Prepare product lauch | 2020-11-17 → 2021-06-21 (+216d) | 2020-12-07 → 2021-07-09 (+214d) |  |  | was named Prepare product launch; resources none → QUAL [300%]; PURCH [200%]; PROD [1500%]; MRKT [500%]; ENG [500%]; R&D |

## Version 5 (saved 2020-06-13, file yourlastname-POM 3.mpp)

Last finish 2021-07-09 → 2021-08-09 (+31d). Complete tasks 0 → 3.

Changed:

| ID | Task | Start | Finish | Duration | Complete | Total float | Other |
| --- | --- | --- | --- | --- | --- | --- | --- |
| 1 | **POM+Project** | 2021-01-04 A | 2021-07-09 → 2021-08-09 (+31d) | 135d → 156d | 0% → 26% |  | baseline start none → 2021-01-04; baseline finish none → 2021-07-09 |
| 2 | **R&D product development** | 2021-01-04 A | 2021-04-02 → 2021-04-13 (+11d) | 65d → 71.67d | 0% → 70% | 0d → 14.33d | baseline start none → 2021-01-04; baseline finish none → 2021-04-02 |
| 3 | Need survey | 2021-01-04 A | 2021-01-29 → 2021-02-02 A (+4d) | 20d → 22d | 0% → 100% | 0d → none | baseline start none → 2021-01-04; baseline finish none → 2021-01-29 |
| 4 | Set product specs | 2021-02-01 → 2021-02-03 A (+2d) | 2021-02-19 → 2021-02-26 A (+7d) | 15d → 18d | 0% → 100% | 0d → none | baseline start none → 2021-02-01; baseline finish none → 2021-02-19 |
| 5 | Shelf life report | 2021-02-22 → 2021-02-27 A (+5d) | 2021-03-05 → 2021-03-12 A (+7d) |  | 0% → 100% | 0d → none | baseline start none → 2021-02-22; baseline finish none → 2021-03-05 |
| 6 | Nutrition report | 2021-03-04 → 2021-03-15 (+11d) | 2021-03-05 → 2021-03-16 (+11d) |  |  | 0d → 14.33d | baseline start none → 2021-03-04; baseline finish none → 2021-03-05 |
| 7 | Select fruit suppliers | 2021-03-08 → 2021-03-16 (+8d) | 2021-04-02 → 2021-04-13 (+11d) |  |  | 0d → 14.33d | baseline start none → 2021-03-08; baseline finish none → 2021-04-02 |
| 8 | **Initial Praduction** | 2021-02-22 → 2021-03-23 A (+29d) | 2021-06-18 → 2021-07-19 (+31d) |  | 0% → 27% |  | baseline start none → 2021-02-22; baseline finish none → 2021-06-18 |
| 9 | Equipmant rabab | 2021-02-22 → 2021-03-23 A (+29d) | 2021-04-02 → 2021-05-03 (+31d) |  | 0% → 77% |  | baseline start none → 2021-02-22; baseline finish none → 2021-04-02 |
| 10 | Production trials | 2021-04-05 → 2021-05-04 (+29d) | 2021-04-23 → 2021-05-24 (+31d) |  |  |  | baseline start none → 2021-04-05; baseline finish none → 2021-04-23 |
| 11 | Quality trials | 2021-04-26 → 2021-05-25 (+29d) | 2021-05-21 → 2021-06-21 (+31d) |  |  |  | baseline start none → 2021-04-26; baseline finish none → 2021-05-21 |
| 12 | Quality metrics | 2021-05-24 → 2021-06-22 (+29d) | 2021-05-28 → 2021-06-28 (+31d) |  |  |  | baseline start none → 2021-05-24; baseline finish none → 2021-05-28 |
| 13 | Quality training | 2021-05-31 → 2021-06-29 (+29d) | 2021-06-18 → 2021-07-19 (+31d) |  |  |  | baseline start none → 2021-05-31; baseline finish none → 2021-06-18 |
| 14 | **Distribution** | 2021-03-08 → 2021-03-16 (+8d) | 2021-06-11 → 2021-06-22 (+11d) |  |  | 5d → 19.33d | baseline start none → 2021-03-08; baseline finish none → 2021-06-11 |
| 15 | Market testing | 2021-03-08 → 2021-03-16 (+8d) | 2021-04-16 → 2021-04-27 (+11d) |  |  | 5d → 19.33d | baseline start none → 2021-03-08; baseline finish none → 2021-04-16 |
| 16 | Package design | 2021-04-19 → 2021-04-27 (+8d) | 2021-06-11 → 2021-06-22 (+11d) |  |  | 5d → 19.33d | baseline start none → 2021-04-19; baseline finish none → 2021-06-11 |
| 17 | Select distributors | 2021-04-19 → 2021-04-27 (+8d) | 2021-05-21 → 2021-06-01 (+11d) |  |  | 20d → 34.33d | baseline start none → 2021-04-19; baseline finish none → 2021-05-21 |
| 18 | **Legal** | 2021-04-19 → 2021-04-27 (+8d) | 2021-05-14 → 2021-05-25 (+11d) | 20d → 19.67d |  | 5d → 19.33d | baseline start none → 2021-04-19; baseline finish none → 2021-05-14 |
| 19 | Complete FDA certification | 2021-04-19 → 2021-04-27 (+8d) | 2021-05-07 → 2021-05-18 (+11d) |  |  | 5d → 19.33d | baseline start none → 2021-04-19; baseline finish none → 2021-05-07 |
| 20 | Register trademark | 2021-05-10 → 2021-04-27 (-13d) | 2021-05-14 → 2021-05-25 (+11d) |  |  | 10d → 24.67d | baseline start none → 2021-05-10; baseline finish none → 2021-05-14 |
| 21 | Prepare product lauch | 2021-06-21 → 2021-07-20 (+29d) | 2021-07-09 → 2021-08-09 (+31d) |  |  |  | baseline start none → 2021-06-21; baseline finish none → 2021-07-09 |

## Version 6 (saved 2020-06-17, file yourlastname-POM 4.mpp)

Last finish 2021-08-09 → 2021-07-26 (-14d). Complete tasks 3 → 11.

Changed:

| ID | Task | Start | Finish | Duration | Complete | Total float |
| --- | --- | --- | --- | --- | --- | --- |
| 1 | **POM+Project** | 2021-01-04 A → 2020-07-02 A (-186d) | 2021-08-09 → 2021-07-26 (-14d) | 156d → 277d | 26% → 72% |  |
| 2 | **R&D product development** | 2021-01-04 A → 2020-07-02 A (-186d) | 2021-04-13 → 2021-03-22 A (-22d) | 71.67d → 187d | 70% → 100% | 14.33d → none |
| 6 | Nutrition report | 2021-03-15 A | 2021-03-16 → 2021-03-22 A (+6d) | 1.67d → 6d | 0% → 100% | 14.33d → none |
| 7 | Select fruit suppliers | 2021-03-16 → 2020-07-02 A (-257d) | 2021-04-13 → 2020-07-02 A (-285d) | 20d → 0d | 0% → 100% | 14.33d → none |
| 8 | **Initial Praduction** | 2021-03-23 A → 2021-03-01 A (-22d) | 2021-07-19 → 2021-06-30 (-19d) | 85d → 87d | 27% → 75% | 0d → 3d |
| 9 | Equipmant rabab | 2021-03-23 A → 2021-03-01 A (-22d) | 2021-05-03 → 2021-04-12 A (-21d) |  | 77% → 100% | 0d → none |
| 10 | Production trials | 2021-05-04 → 2021-04-19 A (-15d) | 2021-05-24 → 2021-05-05 A (-19d) | 15d → 13d | 0% → 100% | 0d → none |
| 11 | Quality trials | 2021-05-25 → 2021-05-10 A (-15d) | 2021-06-21 → 2021-06-02 A (-19d) | 20d → 18d | 0% → 100% | 0d → none |
| 12 | Quality metrics | 2021-06-22 → 2021-06-03 (-19d) | 2021-06-28 → 2021-06-09 (-19d) |  |  | 0d → 3d |
| 13 | Quality training | 2021-06-29 → 2021-06-10 (-19d) | 2021-07-19 → 2021-06-30 (-19d) |  |  | 0d → 3d |
| 14 | **Distribution** | 2021-03-16 → 2021-04-05 A (+20d) | 2021-06-22 → 2021-07-01 (+9d) | 70d → 64d | 0% → 60% | 19.33d → 2d |
| 15 | Market testing | 2021-03-16 → 2021-04-05 A (+20d) | 2021-04-27 → 2021-05-11 A (+14d) | 30d → 27d | 0% → 100% | 19.33d → none |
| 16 | Package design | 2021-04-27 → 2021-05-11 A (+14d) | 2021-06-22 → 2021-05-26 A (-27d) | 30d → 11d | 0% → 100% | 19.33d → none |
| 17 | Select distributors | 2021-04-27 → 2021-05-28 A (+31d) | 2021-06-01 → 2021-07-01 (+30d) |  |  | 34.33d → 2d |
| 18 | **Legal** | 2021-04-27 → 2021-05-05 A (+8d) | 2021-05-25 → 2021-06-07 (+13d) | 19.67d → 24d | 0% → 74% | 19.33d → 5d |
| 19 | Complete FDA certification | 2021-04-27 → 2021-05-05 A (+8d) | 2021-05-18 → 2021-05-31 A (+13d) | 15d → 14d | 0% → 100% | 19.33d → none |
| 20 | Register trademark | 2021-04-27 → 2021-06-01 (+35d) | 2021-05-25 → 2021-06-07 (+13d) |  |  | 24.67d → 5d |
| 21 | Prepare product lauch | 2021-07-20 → 2021-07-06 (-14d) | 2021-08-09 → 2021-07-26 (-14d) |  |  |  |

## Version 7 (saved 2020-07-27, file Part1 (1).mpp)

Last finish 2021-07-26 → 2021-10-06 (+72d). Complete tasks 11 → 0.

Changed:

| ID | Task | Start | Finish | Duration | Complete | Total float | Other |
| --- | --- | --- | --- | --- | --- | --- | --- |
| 1 | **POM+Project** | 2020-07-02 A → 2021-04-01 (+273d) | 2021-07-26 → 2021-10-06 (+72d) | 277d → 135d | 72% → 0% |  | baseline start 2021-01-04 → none; baseline finish 2021-07-09 → none |
| 2 | **R&D product development** | 2020-07-02 A → 2021-04-01 (+273d) | 2021-03-22 A → 2021-06-30 (+100d) | 187d → 65d | 100% → 0% | none → 0d | baseline start 2021-01-04 → none; baseline finish 2021-04-02 → none |
| 3 | Need survey | 2021-01-04 A → 2021-04-01 (+87d) | 2021-02-02 A → 2021-04-28 (+85d) | 22d → 20d | 100% → 0% | none → 0d | constraint start no earlier than 2021-01-04 → start no earlier than 2021-04-01; resources MRKT → none; baseline start 2021-01-04 → none; baseline finish 2021-01-29 → none |
| 4 | Set product specs | 2021-02-03 A → 2021-04-29 (+85d) | 2021-02-26 A → 2021-05-19 (+82d) | 18d → 15d | 100% → 0% | none → 0d | resources R&D [400%]; MRKT [200%] → none; baseline start 2021-02-01 → none; baseline finish 2021-02-19 → none |
| 5 | Shelf life report | 2021-02-27 A → 2021-05-20 (+82d) | 2021-03-12 A → 2021-06-02 (+82d) |  | 100% → 0% | none → 0d | resources R&D [300%] → none; baseline start 2021-02-22 → none; baseline finish 2021-03-05 → none |
| 6 | Nutrition report | 2021-03-15 A → 2021-05-20 (+66d) | 2021-03-22 A → 2021-05-26 (+65d) | 6d → 5d | 100% → 0% | none → 5d | resources R&D [300%] → none; baseline start 2021-03-04 → none; baseline finish 2021-03-05 → none |
| 7 | Secure fruit suppliers | 2020-07-02 A → 2021-06-03 (+336d) | 2020-07-02 A → 2021-06-30 (+363d) | 0d → 20d | 100% → 0% | none → 0d | was named Select fruit suppliers; resources PURCH → none; baseline start 2021-03-08 → none; baseline finish 2021-04-02 → none |
| 8 | **Initial Production** | 2021-03-01 A → 2021-05-20 (+80d) | 2021-06-30 → 2021-09-15 (+77d) | 87d → 85d | 75% → 0% | 3d → 0d | was named Initial Praduction; baseline start 2021-02-22 → none; baseline finish 2021-06-18 → none |
| 9 | Equipment rabab | 2021-03-01 A → 2021-05-20 (+80d) | 2021-04-12 A → 2021-06-30 (+79d) |  | 100% → 0% | none → 0d | was named Equipmant rabab; resources ENG [1000%]; PROD [2000%] → none; baseline start 2021-02-22 → none; baseline finish 2021-04-02 → none |
| 10 | Production trials | 2021-04-19 A → 2021-07-01 (+73d) | 2021-05-05 A → 2021-07-21 (+77d) | 13d → 15d | 100% → 0% | none → 0d | resources PROD [1500%]; PURCH; ENG [1000%] → none; baseline start 2021-04-05 → none; baseline finish 2021-04-23 → none |
| 11 | Quality trials | 2021-05-10 A → 2021-07-22 (+73d) | 2021-06-02 A → 2021-08-18 (+77d) | 18d → 20d | 100% → 0% | none → 0d | resources QUAL [300%]; PROD [500%] → none; baseline start 2021-04-26 → none; baseline finish 2021-05-21 → none |
| 12 | Quality metrics | 2021-06-03 → 2021-08-19 (+77d) | 2021-06-09 → 2021-08-25 (+77d) |  |  | 3d → 0d | resources QUAL [300%]; PROD → none; baseline start 2021-05-24 → none; baseline finish 2021-05-28 → none |
| 13 | Quality training | 2021-06-10 → 2021-08-26 (+77d) | 2021-06-30 → 2021-09-15 (+77d) |  |  | 3d → 0d | resources QUAL [300%]; PROD → none; baseline start 2021-05-31 → none; baseline finish 2021-06-18 → none |
| 14 | **Distribution** | 2021-04-05 A → 2021-06-03 (+59d) | 2021-07-01 → 2021-08-18 (+48d) | 64d → 55d | 60% → 0% | 2d → 5d | baseline start 2021-03-08 → none; baseline finish 2021-06-11 → none |
| 15 | Market testing | 2021-04-05 A → 2021-06-03 (+59d) | 2021-05-11 A → 2021-07-14 (+64d) | 27d → 30d | 100% → 0% | none → 5d | resources MRKT [500%] → none; baseline start 2021-03-08 → none; baseline finish 2021-04-16 → none |
| 16 | Package design | 2021-05-11 A → 2021-07-15 (+65d) | 2021-05-26 A → 2021-08-04 (+70d) | 11d → 15d | 100% → 0% | none → 30d | resources DESIGN [300%]; MRKT → none; baseline start 2021-04-19 → none; baseline finish 2021-06-11 → none |
| 17 | Select distributors | 2021-05-28 A → 2021-07-15 (+48d) | 2021-07-01 → 2021-08-18 (+48d) |  |  | 2d → 20d | resources MRKT [500%] → none; baseline start 2021-04-19 → none; baseline finish 2021-05-21 → none |
| 18 | **Legal** | 2021-05-05 A → 2021-07-15 (+71d) | 2021-06-07 → 2021-08-04 (+58d) | 24d → 15d | 74% → 0% |  | baseline start 2021-04-19 → none; baseline finish 2021-05-14 → none |
| 19 | Complete FDA certification | 2021-05-05 A → 2021-07-15 (+71d) | 2021-05-31 A → 2021-08-04 (+65d) | 14d → 15d | 100% → 0% | none → 5d | resources LEGAL [500%] → none; baseline start 2021-04-19 → none; baseline finish 2021-05-07 → none |
| 20 | Register trademark | 2021-06-01 → 2021-07-15 (+44d) | 2021-06-07 → 2021-07-21 (+44d) |  |  | 5d → 25d | resources LEGAL [300%] → none; baseline start 2021-05-10 → none; baseline finish 2021-05-14 → none |
| 21 | Prepare product launch | 2021-07-06 → 2021-09-16 (+72d) | 2021-07-26 → 2021-10-06 (+72d) |  |  |  | was named Prepare product lauch; resources QUAL [300%]; PURCH [200%]; PROD [1500%]; MRKT [500%]; ENG [500%]; R&D → none; baseline start 2021-06-21 → none; baseline finish 2021-07-09 → none |
