How a schedule from MS Project changed from version to version. A marks actual dates.

## Version 1 (saved 2018-07-18, file Greendale Stadium Case.mpp)

| ID | WBS | Task | Duration | Start | Finish | Predecessors | Total float |
| --- | --- | --- | --- | --- | --- | --- | --- |
| 1 | 1 | **Baseball Stadium** | 1677d | 2011-07-01 | 2017-12-25 |  | 0d |
| 2 |  | Clear Stadium site | 70d | 2011-07-01 | 2011-10-10 |  |  |
| 3 |  | Demolish building | 30d | 2011-10-10 | 2011-11-18 | 2 |  |
| 4 |  | Set up construction site | 70d | 2011-11-18 | 2012-02-24 | 3 |  |
| 5 |  | Drive support piling | 120d | 2012-02-24 | 2012-08-13 | 2 |  |
| 6 |  | Pour lower concrete bowl | 120d | 2012-08-13 | 2013-01-31 | 5 |  |
| 7 |  | Pour main concourse | 120d | 2013-01-31 | 2013-07-19 | 3, 6 |  |
| 8 |  | Install playing field | 90d | 2013-07-19 | 2013-11-22 | 3, 6 |  |
| 9 |  | Construct upper steel bowl | 120d | 2013-11-22 | 2014-05-13 | 3, 6 |  |
| 10 |  | Install seats | 140d | 2014-05-13 | 2014-11-24 | 7, 9 |  |
| 11 |  | Build luxury boxes | 90d | 2014-11-24 | 2015-03-27 | 7, 9 |  |
| 12 |  | Install jumbotron | 30d | 2015-03-27 | 2015-05-07 | 7, 9 |  |
| 13 |  | Stadium infrastructure | 120d | 2015-05-07 | 2015-10-21 | 7, 9 |  |
| 14 |  | Construct steel canopy | 75d | 2015-10-21 | 2016-02-02 | 10 |  |
| 15 |  | Light installation | 30d | 2016-02-02 | 2016-03-14 | 14 |  |
| 16 |  | Build roof supports | 90d | 2016-03-14 | 2016-07-15 | 6 |  |
| 17 |  | Construct roof | 180d | 2016-07-15 | 2017-03-23 | 16 |  |
| 18 |  | Install roof tracks | 90d | 2017-03-23 | 2017-07-26 | 16 |  |
| 19 |  | Install roof | 90d | 2017-07-26 | 2017-11-28 | 17, 18 |  |
| 20 |  | Inspection | 20d | 2017-11-28 | 2017-12-25 | 8, 11, 13, 15, 19 |  |

## Version 2 (saved 2021-09-15, file Project3.mpp)

Last finish 2017-12-25 → 2021-02-12 (+1145d).

Changed:

| ID | Task | Start | Finish | Duration | Total float | Predecessors | Other |
| --- | --- | --- | --- | --- | --- | --- | --- |
| 1 | Baseball Stadium | 2011-07-01 → 2017-07-03 A (+2194d) | 2017-12-25 → 2021-02-12 (+1145d) | 1677d → 945d |  |  |  |
| 2 | Clear Stadium site | 2011-07-01 → 2017-07-03 (+2194d) | 2011-10-10 → 2017-10-06 (+2188d) |  | none → 0d |  |  |
| 3 | Demolish Building | 2011-10-10 → 2017-10-09 (+2191d) | 2011-11-18 → 2017-11-17 (+2191d) |  | none → 0d |  | was named Demolish building |
| 4 | Setup Construction site | 2011-11-18 → 2017-11-20 (+2194d) | 2012-02-24 → 2018-02-23 (+2191d) |  | none → 0d |  | was named Set up construction site |
| 5 | Drive Support Piling | 2012-02-24 → 2018-02-26 (+2194d) | 2012-08-13 → 2018-08-10 (+2188d) |  | none → 0d | 2 → 4 | was named Drive support piling |
| 6 | Power lower concrete bowl | 2012-08-13 → 2018-08-13 (+2191d) | 2013-01-31 → 2019-01-25 (+2185d) |  | none → 0d |  | was named Pour lower concrete bowl |
| 7 | Power Main Concourse | 2013-01-31 → 2019-01-28 (+2188d) | 2013-07-19 → 2019-07-12 (+2184d) |  | none → 415d | 3, 6 → 6 | was named Pour main concourse |
| 8 | Install Playing Field | 2013-07-19 → 2019-01-28 (+2019d) | 2013-11-22 → 2019-05-31 (+2016d) |  | none → 425d | 3, 6 → 6 | was named Install playing field |
| 9 | Construct upper steel bowl | 2013-11-22 → 2019-01-28 (+1893d) | 2014-05-13 → 2019-07-12 (+1886d) |  | none → 0d | 3, 6 → 6 |  |
| 10 | Install seats | 2014-05-13 → 2019-07-15 (+1889d) | 2014-11-24 → 2020-01-24 (+1887d) |  | none → 0d | 7, 9 → 9 |  |
| 11 | Build luxury boxes | 2014-11-24 → 2019-07-15 (+1694d) | 2015-03-27 → 2019-11-15 (+1694d) |  | none → 305d | 7, 9 → 9 |  |
| 12 | Install jumbotron | 2015-03-27 → 2019-07-15 (+1571d) | 2015-05-07 → 2019-08-23 (+1569d) |  | none → 385d | 7, 9 → 9 |  |
| 13 | Stadium infrastructure | 2015-05-07 → 2019-07-15 (+1530d) | 2015-10-21 → 2019-12-27 (+1528d) |  | none → 275d | 7, 9 → 9 |  |
| 14 | Construct steel canopy | 2015-10-21 → 2020-01-27 (+1559d) | 2016-02-02 → 2020-05-08 (+1557d) |  | none → 0d |  |  |
| 15 | Light installation | 2016-02-02 → 2020-01-27 (+1455d) | 2016-03-14 → 2020-03-06 (+1453d) |  | none → 225d | 14 → 10 |  |
| 16 | Build roof supports | 2016-03-14 → 2018-02-26 (+714d) | 2016-07-15 → 2018-06-29 (+714d) |  | none → 395d | 6 → 4 |  |
| 17 | Construct roof | 2016-07-15 → 2018-07-02 (+717d) | 2017-03-23 → 2019-03-08 (+715d) |  | none → 395d |  |  |
| 18 | Install roof tracks | 2017-03-23 → 2020-05-11 (+1145d) | 2017-07-26 → 2020-09-11 (+1143d) |  | none → 0d | 16 → 14 |  |
| 19 | Install roof | 2017-07-26 → 2020-09-14 (+1146d) | 2017-11-28 → 2021-01-15 (+1144d) |  | none → 0d |  |  |
| 20 | Inspection | 2017-11-28 → 2021-01-18 (+1147d) | 2017-12-25 → 2021-02-12 (+1145d) |  | none → 0d |  |  |
